# detail_inception_iteration

How a schedule from MS Project changed from version to version. A marks actual dates.

## Version 1 (saved 1999-05-08, file detail_inception_iter_19990507.mpp)

| ID | WBS | Task | Duration | Start | Finish | Predecessors | Complete | Total float | Constraint |
| --- | --- | --- | --- | --- | --- | --- | --- | --- | --- |
| 1 | 1 | **Inception Phase** | 92d | 1999-05-03 A | 1999-09-07 |  | 7% | 0d |  |
| 2 | 1.1 | **Project Management** | 92d | 1999-05-03 A | 1999-09-07 |  | 12% | 0d |  |
| 3 | 1.1.1 | **Conceive New Project** | 3d | 1999-05-03 A | 1999-05-05 A |  | 100% |  |  |
| 4 |  | Identify and Assess Risks | 2d | 1999-05-03 A | 1999-05-04 A |  | 100% |  |  |
| 5 |  | Develop Business Case | 1d | 1999-05-04 A | 1999-05-04 A | 4 | 100% |  |  |
| 6 |  | Initiate Project | 1d | 1999-05-05 A | 1999-05-05 A | 5 | 100% |  |  |
| 7 |  | Project Approval Review | 1d | 1999-05-05 A | 1999-05-05 A | 6FF | 100% |  |  |
| 8 | 1.1.2 | **Evaluate Project Scope and Risk** | 3d | 1999-05-06 A | 1999-05-10 A | 4, 3 | 100% |  |  |
| 9 |  | Identify and Assess Risks | 3d | 1999-05-06 A | 1999-05-10 A |  | 100% |  |  |
| 10 |  | Develop Business Case | 1d | 1999-05-07 A | 1999-05-07 A | 9 | 100% |  |  |
| 11 | 1.1.3 | **Develop Software Development Plan** | 33d | 1999-06-01 | 1999-07-15 | 52SS, 8 |  | 0d |  |
| 12 |  | Develop Measurement Plan | 5d | 1999-06-01 | 1999-06-08 |  |  | 0d | finish no earlier than 1999-06-04 |
| 13 |  | Develop Risk Management Plan | 1d | 1999-06-08 | 1999-06-15 | 12 |  | 0d |  |
| 14 |  | Develop Product Acceptance Plan | 1d | 1999-06-15 | 1999-06-21 | 13 |  | 0d |  |
| 15 |  | Develop Problem Resolution Plan | 1d | 1999-06-22 | 1999-06-28 | 14 |  | 0d |  |
| 16 |  | Define Project Organization and Staffing | 1d | 1999-06-28 | 1999-07-01 | 15 |  | 0d |  |
| 17 |  | Define Monitoring & Control Processes | 1d | 1999-07-01 | 1999-07-07 | 16 |  | 0d |  |
| 18 |  | Plan Phases and Iterations | 1d | 1999-07-07 | 1999-07-12 | 17 |  | 0d |  |
| 19 |  | Compile Software Development Plan | 1d | 1999-07-12 | 1999-07-15 | 18 |  | 0d |  |
| 20 |  | Project Planning Review | 1d | 1999-07-12 | 1999-07-15 | 19FF |  | 0d |  |
| 21 | 1.1.4 | **Plan for Next Iteration** | 3d | 1999-07-16 | 1999-07-20 | 11 |  | 0d |  |
| 22 |  | Develop Iteration Plan | 1d | 1999-07-16 | 1999-07-16 |  |  | 0d |  |
| 23 |  | Develop Business Case | 1d | 1999-07-19 | 1999-07-19 | 22 |  | 0d |  |
| 24 |  | Iteration Plan Review | 1d | 1999-07-20 | 1999-07-20 | 23 |  | 0d |  |
| 25 | 1.1.5 | **Manage Iteration** | 43.8d | 1999-06-17 A | 1999-08-17 | 21 | 2% | 13d |  |
| 26 |  | Acquire Staff | 5d | 1999-06-17 A | 1999-07-27 |  | 10% | 0.5d |  |
| 27 |  | Initiate Iteration | 5d | 1999-07-27 | 1999-08-03 | 26 |  | 0.5d |  |
| 28 |  | Assess Iteration | 5d | 1999-08-04 | 1999-08-10 | 73FF, 27 |  | 0d |  |
| 29 |  | Iteration Evaluation Criteria Review | 5d | 1999-08-04 | 1999-08-10 | 28FF |  | 13d |  |
| 30 |  | Iteration Acceptance Review | 5d | 1999-08-11 | 1999-08-17 | 29 |  | 13d |  |
| 31 | 1.1.6 | **Monitor and Control Project** | 20d | 1999-08-11 | 1999-09-07 | 11, 25SS |  | 0d |  |
| 32 |  | Schedule and Assign Work | 5d | 1999-08-11 | 1999-08-17 | 26, 27, 28 |  | 0d |  |
| 33 |  | Monitor Project Status | 5d | 1999-08-18 | 1999-08-24 | 32 |  | 0d |  |
| 34 |  | Report Status | 5d | 1999-08-25 | 1999-08-31 | 33 |  | 0d |  |
| 35 |  | Handle Exceptions and Problems | 5d | 1999-09-01 | 1999-09-07 | 34 |  | 0d |  |
| 36 |  | Project Review Authority (PRA) Project Review | 5d | 1999-09-01 | 1999-09-07 | 35FF |  | 0d |  |
| 37 | 1.1.7 | **Reevaluate Project Scope and Risk** | 2d | 1999-08-18 | 1999-08-19 | 25, 65SS |  | 13d |  |
| 38 |  | Identify and Assess Risks | 1d | 1999-08-18 | 1999-08-18 |  |  | 13d |  |
| 39 |  | Develop Business Case | 1d | 1999-08-19 | 1999-08-19 | 38 |  | 13d |  |
| 40 | 1.2 | **Requirements** | 68.2d | 1999-05-03 A | 1999-08-05 |  | 10% | 23.8d |  |
| 41 | 1.2.1 | **Analyze the Problem** | 16d | 1999-05-03 A | 1999-05-24 | 3SS, 46SS | 40% | 55.8d |  |
| 42 |  | Capture a Common Vocabulary | 4d | 1999-05-03 A | 1999-05-07 |  | 70% | 59.2d |  |
| 43 |  | Find Actors and Use Cases | 4d | 1999-05-07 A | 1999-05-12 | 42 | 90% | 55.8d |  |
| 44 |  | Develop Vision | 4d | 1999-05-13 | 1999-05-18 | 43 |  | 55.8d |  |
| 45 |  | Develop Requirements Management Plan | 4d | 1999-05-19 | 1999-05-24 | 44 |  | 55.8d |  |
| 46 | 1.2.2 | **Understand Stakeholder Needs** | 20d | 1999-05-04 A | 1999-05-31 | 3SS | 14% | 50.8d |  |
| 47 |  | Capture a Common Vocabulary | 4d | 1999-05-04 A | 1999-05-07 |  | 50% | 51.6d | finish no earlier than 1999-05-07 |
| 48 |  | Elicit Stakeholder Requests | 4d | 1999-05-10 A | 1999-05-13 | 47 | 20% | 50.8d |  |
| 49 |  | Develop Vision | 4d | 1999-05-14 | 1999-05-19 | 48 |  | 50.8d |  |
| 50 |  | Find Actors and Use Cases | 4d | 1999-05-20 | 1999-05-25 | 49 |  | 50.8d |  |
| 51 |  | Manage Dependencies | 4d | 1999-05-26 | 1999-05-31 | 50 |  | 50.8d |  |
| 52 | 1.2.3 | **Define the System** | 9d | 1999-06-01 | 1999-06-11 | 41, 46 |  | 50.8d |  |
| 53 |  | Capture a Common Vocabulary | 3d | 1999-06-01 | 1999-06-03 |  |  | 50.8d |  |
| 54 |  | Find Actors and Use Cases | 3d | 1999-06-04 | 1999-06-08 | 53 |  | 50.8d |  |
| 55 |  | Manage Dependencies | 3d | 1999-06-09 | 1999-06-11 | 54 |  | 50.8d |  |
| 56 | 1.2.4 | **Manage the Scope of the System** | 8d | 1999-06-02 | 1999-06-11 | 52SS+1d |  | 55.8d |  |
| 57 |  | Develop Vision | 3d | 1999-06-04 | 1999-06-08 | 53 |  | 65d |  |
| 58 |  | Manage Dependencies | 3d | 1999-06-09 | 1999-06-11 | 54 |  | 62d |  |
| 59 |  | Prioritize Use Cases | 3d | 1999-06-02 | 1999-06-04 |  |  | 55.8d |  |
| 60 | 1.2.5 | **Refine the System Definition** | 11.2d | 1999-07-21 | 1999-08-05 | 21, 52, 59 |  | 23.8d |  |
| 61 |  | Detail a Use Case | 4d | 1999-07-21 | 1999-07-28 |  |  | 23.8d |  |
| 62 |  | Detail the Software Requirements | 4d | 1999-07-28 | 1999-08-05 | 61 |  | 23.8d |  |
| 63 |  | Model the User Interface | 4d | 1999-07-21 | 1999-07-28 |  |  | 23.8d |  |
| 64 |  | Prototype the User Interface | 4d | 1999-07-28 | 1999-08-05 | 63 |  | 23.8d |  |
| 65 | 1.2.6 | **Manage Changing Requirements** | 16d | 1999-05-26 | 1999-06-16 | 41SS+2d |  | 57.1d |  |
| 66 |  | Structure the Use-Case Model | 8d | 1999-05-26 | 1999-06-04 | 49, 50 |  | 57.1d |  |
| 67 |  | Manage Dependencies | 8d | 1999-06-07 | 1999-06-16 | 66 |  | 57.1d |  |
| 68 |  | Review Requirements | 8d | 1999-06-04 | 1999-06-16 | 67FF |  | 59d |  |
| 69 | 1.3 | **Analysis and Design** | 15d | 1999-07-21 | 1999-08-10 |  |  | 0d |  |
| 70 | 1.3.1 | **Perform Architectural Synthesis** | 15d | 1999-07-21 | 1999-08-10 | 21 |  | 0d |  |

| ID | WBS | Task | Duration | Start | Finish | Predecessors | Complete | Total float |
| --- | --- | --- | --- | --- | --- | --- | --- | --- |
| 71 |  | Architectural Analysis | 5d | 1999-07-21 | 1999-07-27 |  |  | 0d |
| 72 |  | Construct Architectural Proof-of-Concept | 5d | 1999-07-28 | 1999-08-03 | 71 |  | 0d |
| 73 |  | Assess Viability of Architectural Proof-of-Concept | 5d | 1999-08-04 | 1999-08-10 | 72 |  | 0d |
| 74 | 1.4 | **Test** | 1d | 1999-06-01 | 1999-06-01 |  |  | 70d |
| 75 | 1.4.1 | **Plan Test** | 1d | 1999-06-01 | 1999-06-01 | 11SS |  | 70d |
| 76 |  | Plan Test | 1d | 1999-06-01 | 1999-06-01 |  |  | 70d |
| 77 | 1.5 | **Environment** | 61.6d | 1999-05-06 A | 1999-07-30 |  | 11% | 27.4d |
| 78 | 1.5.1 | **Prepare Environment for Project** | 3d | 1999-05-06 A | 1999-05-10 | 3 | 65% | 75.4d |
| 79 |  | Assess Current Organization | 1d | 1999-05-06 A | 1999-05-06 A |  | 100% |  |
| 80 |  | Develop Development Case | 1d | 1999-05-07 A | 1999-05-07 | 79 | 80% | 75.4d |
| 81 |  | Develop Project-Specific Templates | 1d | 1999-05-10 | 1999-05-10 | 80 |  | 75.4d |
| 82 |  | Select & Acquire Tools | 1d | 1999-05-06 A | 1999-05-06 |  | 80% | 77.4d |
| 83 | 1.5.2 | **Prepare Environment for an Iteration** | 3d | 1999-07-16 | 1999-07-20 | 21SS, 78 |  | 27.4d |
| 84 |  | Develop Development Case | 1d | 1999-07-16 | 1999-07-16 |  |  | 27.4d |
| 85 |  | Develop Project-Specific Templates | 1d | 1999-07-19 | 1999-07-19 | 84 |  | 27.4d |
| 86 |  | Launch Development Case | 1d | 1999-07-20 | 1999-07-20 | 85 |  | 27.4d |
| 87 |  | Set Up Tools | 1d | 1999-07-16 | 1999-07-16 | 82 |  | 28.4d |
| 88 |  | Verify Tool Configuration & Installation | 1d | 1999-07-19 | 1999-07-19 | 87 |  | 28.4d |
| 89 | 1.5.3 | **Prepare Guidelines for an Iteration** | 6.1d | 1999-07-16 | 1999-07-26 | 78, 21SS |  | 31.9d |
| 90 |  | Develop Business-Modeling Guidelines | 1d | 1999-07-16 | 1999-07-21 |  |  | 34.9d |
| 91 |  | Develop Use-Case Modeling Guidelines | 1d | 1999-07-16 | 1999-07-19 | 67 |  | 36.1d |
| 92 |  | Develop User-Interface Guidelines | 1d | 1999-07-16 | 1999-07-21 |  |  | 34.9d |
| 93 |  | Develop Design Guidelines | 1d | 1999-07-16 | 1999-07-21 |  |  | 33.9d |
| 94 |  | Develop Programming Guidelines | 1d | 1999-07-21 | 1999-07-22 | 93 |  | 33.9d |
| 95 |  | Develop Manual Styleguide | 1d | 1999-07-16 | 1999-07-21 |  |  | 34.9d |
| 96 |  | Develop Test Guidelines | 1d | 1999-07-16 | 1999-07-21 |  |  | 34.9d |
| 97 |  | Develop Tool Guidelines | 1d | 1999-07-21 | 1999-07-26 | 83 |  | 31.9d |
| 98 | 1.5.4 | **Support Environment During an Iteration** | 7.6d | 1999-07-21 | 1999-07-30 | 83 |  | 27.4d |
| 99 |  | Support Development | 6d | 1999-07-21 | 1999-07-30 |  |  | 27.4d |
| 100 | 1.6 | **Configuration & Change Management** | 79.7d | 1999-05-06 A | 1999-08-25 |  |  | 9.3d |
| 101 | 1.6.1 | **Plan Project Configuration and Change Control** | 3d | 1999-05-06 A | 1999-05-10 | 3 | 10% | 57.3d |
| 102 |  | Establish CM Policies | 1d | 1999-05-06 A | 1999-05-06 |  | 20% | 57.4d |
| 103 |  | Write CM Plan | 1d | 1999-05-07 A | 1999-05-07 | 102 | 5% | 57.35d |
| 104 |  | Establish Change Control Process | 1d | 1999-05-10 A | 1999-05-10 | 103 | 5% | 57.3d |
| 105 | 1.6.2 | **Create Project CM Environments** | 3.1d | 1999-07-16 | 1999-07-21 | 21SS, 101 |  | 9.3d |
| 106 |  | Setup CM Environment | 1d | 1999-07-16 | 1999-07-16 |  |  | 11.4d |
| 107 |  | Create Integration Workspaces | 1d | 1999-07-16 | 1999-07-21 |  |  | 9.3d |
| 108 | 1.6.3 | **Change and Deliver Configuration Items** | 25.6d | 1999-07-21 | 1999-08-25 | 105 |  | 9.3d |
| 109 |  | Create Development Workspace | 6d | 1999-07-21 | 1999-07-30 |  |  | 9.3d |
| 110 |  | Make Changes | 6d | 1999-07-30 | 1999-08-09 | 109 |  | 9.3d |
| 111 |  | Deliver Changes | 6d | 1999-08-09 | 1999-08-17 | 110 |  | 9.3d |
| 112 |  | Update Workspace | 6d | 1999-08-17 | 1999-08-25 | 111 |  | 9.3d |
| 113 |  | Create Baselines | 6d | 1999-07-21 | 1999-07-29 |  |  | 10.9d |
| 114 |  | Promote Baselines | 6d | 1999-07-29 | 1999-08-06 | 113 |  | 10.9d |
| 115 | 1.6.4 | **Manage Baselines and Releases** | 24d | 1999-07-21 | 1999-08-24 | 105, 25SS |  | 10.9d |
| 116 |  | Create Deployment Unit | 6d | 1999-07-21 | 1999-07-29 |  |  | 16.9d |
| 117 |  | Create Baselines | 6d | 1999-08-06 | 1999-08-16 | 114 |  | 10.9d |
| 118 |  | Promote Baselines | 6d | 1999-08-16 | 1999-08-24 | 117 |  | 10.9d |
| 119 | 1.6.5 | **Manage Change Requests** | 24d | 1999-07-21 | 1999-08-24 | 105, 25SS |  | 10.9d |
| 120 |  | Submit Change Request | 6d | 1999-07-21 | 1999-07-29 |  |  | 22.9d |
| 121 |  | Update Change Request | 6d | 1999-07-29 | 1999-08-06 | 120 |  | 22.9d |
| 122 |  | Review Change Request | 6d | 1999-07-21 | 1999-07-29 |  |  | 22.9d |
| 123 |  | Confirm Duplicate or Rejected Change Request | 6d | 1999-07-29 | 1999-08-06 | 122 |  | 22.9d |
| 124 |  | Verify Changes in Build | 6d | 1999-08-16 | 1999-08-24 | 118FF |  | 10.9d |
| 125 | 1.6.6 | **Monitor and Report Configuration Status** | 12d | 1999-07-29 | 1999-08-16 | 105, 25SS |  | 16.9d |
| 126 |  | Report on Configuration Status | 6d | 1999-07-29 | 1999-08-06 | 116 |  | 16.9d |
| 127 |  | Perform Configuration Audits | 6d | 1999-08-06 | 1999-08-16 | 126 |  | 16.9d |

## Version 2 (saved 1999-05-15, file detail_inception_iter_19990514.mpp)

Last finish stays 1999-09-07. Complete tasks 7 → 9.

Changed:

| ID | Task | Start | Finish | Complete | Total float |
| --- | --- | --- | --- | --- | --- |
| 1 | **Inception Phase** |  |  | 7% → 9% |  |
| 40 | **Requirements** |  |  | 10% → 18% |  |
| 41 | **Analyze the Problem** |  |  | 40% → 53% |  |
| 42 | Capture a Common Vocabulary |  |  | 70% → 90% | 59.2d → 67.6d |
| 43 | Find Actors and Use Cases |  | 1999-05-12 A | 90% → 100% | 55.8d → none |
| 44 | Develop Vision | 1999-05-13 A |  | 0% → 20% |  |
| 46 | **Understand Stakeholder Needs** |  |  | 14% → 41% |  |
| 47 | Capture a Common Vocabulary |  | 1999-05-07 A | 50% → 100% | 51.6d → none |
| 48 | Elicit Stakeholder Requests |  |  | 20% → 90% | 50.8d → 51.4d |
| 49 | Develop Vision | 1999-05-14 A |  | 0% → 15% |  |

## Version 3 (saved 1999-05-22, file detail_inception_iter_19990521.mpp)

Last finish stays 1999-09-07. Complete tasks 9 → 13.

Changed:

| ID | Task | Start | Finish | Complete | Total float |
| --- | --- | --- | --- | --- | --- |
| 1 | **Inception Phase** |  |  | 9% → 14% |  |
| 40 | **Requirements** |  |  | 18% → 31% |  |
| 41 | **Analyze the Problem** |  |  | 53% → 95% |  |
| 42 | Capture a Common Vocabulary |  | 1999-05-07 A | 90% → 100% | 67.6d → none |
| 44 | Develop Vision |  | 1999-05-18 A | 20% → 100% | 55.8d → none |
| 45 | Develop Requirements Management Plan | 1999-05-19 A |  | 0% → 80% |  |
| 46 | **Understand Stakeholder Needs** |  |  | 41% → 72% |  |
| 48 | Elicit Stakeholder Requests |  | 1999-05-13 A | 90% → 100% | 51.4d → none |
| 49 | Develop Vision |  | 1999-05-19 A | 15% → 100% | 50.8d → none |
| 50 | Find Actors and Use Cases | 1999-05-20 A |  | 0% → 60% |  |

## Version 4 (saved 1999-05-29, file detail_inception_iter_19990528.mpp)

Last finish stays 1999-09-07. Complete tasks 13 → 17.

Changed:

| ID | Task | Start | Finish | Complete | Total float |
| --- | --- | --- | --- | --- | --- |
| 1 | **Inception Phase** |  |  | 14% → 17% |  |
| 40 | **Requirements** |  |  | 31% → 40% |  |
| 46 | **Understand Stakeholder Needs** |  |  | 72% → 94% |  |
| 50 | Find Actors and Use Cases |  | 1999-05-25 A | 60% → 100% | 50.8d → none |
| 51 | Manage Dependencies | 1999-05-26 A |  | 0% → 70% |  |
| 65 | **Manage Changing Requirements** | 1999-05-26 A |  | 0% → 17% | 57.1d → 59d |
| 66 | Structure the Use-Case Model | 1999-05-26 A |  | 0% → 50% |  |
| 77 | **Environment** |  |  | 11% → 17% |  |
| 78 | **Prepare Environment for Project** |  | 1999-05-10 A | 65% → 100% | 75.4d → none |
| 80 | Develop Development Case |  | 1999-05-07 A | 80% → 100% | 75.4d → none |
| 81 | Develop Project-Specific Templates | 1999-05-10 A | 1999-05-10 A | 0% → 100% | 75.4d → none |
| 82 | Select & Acquire Tools |  | 1999-05-06 A | 80% → 100% | 77.4d → none |
| 100 | **Configuration & Change Management** |  |  | 0% → 2% |  |
| 101 | **Plan Project Configuration and Change Control** |  |  | 10% → 77% |  |
| 102 | Establish CM Policies |  |  | 20% → 90% | 57.4d → 58.7d |
| 103 | Write CM Plan |  |  | 5% → 70% | 57.35d → 58d |
| 104 | Establish Change Control Process |  |  | 5% → 70% |  |

## Version 5 (saved 1999-06-05, file detail_inception_iter_19990604.mpp)

Last finish stays 1999-09-07. Complete tasks 17 → 22.

Changed:

| ID | Task | Start | Finish | Complete | Total float |
| --- | --- | --- | --- | --- | --- |
| 1 | **Inception Phase** |  |  | 17% → 22% |  |
| 2 | **Project Management** |  |  | 12% → 18% |  |
| 11 | **Develop Software Development Plan** | 1999-06-01 A |  | 0% → 36% |  |
| 12 | Develop Measurement Plan | 1999-06-01 A |  | 0% → 50% | 0d → 18.15d |
| 13 | Develop Risk Management Plan | 1999-06-08 A |  | 0% → 50% | 0d → 13.65d |
| 14 | Develop Product Acceptance Plan | 1999-06-15 A |  | 0% → 50% | 0d → 9.65d |
| 15 | Develop Problem Resolution Plan | 1999-06-22 A |  | 0% → 50% | 0d → 6.05d |
| 16 | Define Project Organization and Staffing | 1999-06-28 A |  | 0% → 50% | 0d → 2.75d |
| 17 | Define Monitoring & Control Processes | 1999-07-01 A |  | 0% → 20% |  |
| 40 | **Requirements** |  |  | 40% → 52% |  |
| 41 | **Analyze the Problem** |  | 1999-05-24 A | 95% → 100% | 55.8d → none |
| 45 | Develop Requirements Management Plan |  | 1999-05-24 A | 80% → 100% | 55.8d → none |
| 46 | **Understand Stakeholder Needs** |  | 1999-05-31 A | 94% → 100% | 50.8d → none |
| 51 | Manage Dependencies |  | 1999-05-31 A | 70% → 100% | 50.8d → none |
| 52 | **Define the System** | 1999-06-01 A |  | 0% → 20% |  |
| 53 | Capture a Common Vocabulary | 1999-06-01 A |  | 0% → 50% | 50.8d → 51.1d |
| 54 | Find Actors and Use Cases | 1999-06-04 A |  | 0% → 10% |  |
| 56 | **Manage the Scope of the System** | 1999-06-02 A |  | 0% → 30% | 55.8d → 62d |
| 57 | Develop Vision | 1999-06-04 A |  | 0% → 10% |  |
| 59 | Prioritize Use Cases | 1999-06-02 A |  | 0% → 80% |  |
| 65 | **Manage Changing Requirements** |  |  | 17% → 33% |  |
| 66 | Structure the Use-Case Model |  |  | 50% → 90% |  |
| 68 | Review Requirements | 1999-06-04 A |  | 0% → 10% |  |
| 100 | **Configuration & Change Management** |  |  | 2% → 3% |  |
| 101 | **Plan Project Configuration and Change Control** |  | 1999-05-10 A | 77% → 100% | 57.3d → none |
| 102 | Establish CM Policies |  | 1999-05-06 A | 90% → 100% | 58.7d → none |
| 103 | Write CM Plan |  | 1999-05-07 A | 70% → 100% | 58d → none |
| 104 | Establish Change Control Process |  | 1999-05-10 A | 70% → 100% | 57.3d → none |

## Version 6 (saved 1999-06-12, file detail_inception_iter_19990611.mpp)

Last finish 1999-09-07 → 1999-08-05 (-33d). Complete tasks 22 → 30.

Changed:

| ID | Task | Start | Finish | Duration | Complete | Total float |
| --- | --- | --- | --- | --- | --- | --- |
| 1 | **Inception Phase** |  | 1999-09-07 → 1999-08-05 (-33d) | 92d → 68.2d | 22% → 32% |  |
| 2 | **Project Management** |  | 1999-09-07 → 1999-08-05 (-33d) | 92d → 68.2d | 18% → 28% |  |
| 11 | **Develop Software Development Plan** | 1999-06-01 A → 1999-05-31 A (-1d) | 1999-07-15 → 1999-06-14 (-31d) | 33d → 10.2d | 36% → 95% | 0d → 0.1d |
| 12 | Develop Measurement Plan | 1999-06-01 A → 1999-05-31 A (-1d) | 1999-06-08 → 1999-06-07 A (-1d) |  | 50% → 100% | 18.15d → none |
| 13 | Develop Risk Management Plan | 1999-06-08 A → 1999-06-01 A (-7d) | 1999-06-15 → 1999-06-07 A (-8d) |  | 50% → 100% | 13.65d → none |
| 14 | Develop Product Acceptance Plan | 1999-06-15 A → 1999-06-02 A (-13d) | 1999-06-21 → 1999-06-08 A (-13d) |  | 50% → 100% | 9.65d → none |
| 15 | Develop Problem Resolution Plan | 1999-06-22 A → 1999-06-03 A (-19d) | 1999-06-28 → 1999-06-09 A (-19d) |  | 50% → 100% | 6.05d → none |
| 16 | Define Project Organization and Staffing | 1999-06-28 A → 1999-06-04 A (-24d) | 1999-07-01 → 1999-06-09 A (-22d) |  | 50% → 100% | 2.75d → none |
| 17 | Define Monitoring & Control Processes | 1999-07-01 A → 1999-06-07 A (-24d) | 1999-07-07 → 1999-06-10 A (-27d) |  | 20% → 100% | 0d → none |
| 18 | Plan Phases and Iterations | 1999-07-07 → 1999-06-08 A (-29d) | 1999-07-12 → 1999-06-11 (-31d) |  | 0% → 80% | 0d → 0.75d |
| 19 | Compile Software Development Plan | 1999-07-12 → 1999-06-09 A (-33d) | 1999-07-15 → 1999-06-14 (-31d) |  | 0% → 80% | 0d → 0.1d |
| 20 | Project Planning Review | 1999-07-12 → 1999-06-09 A (-33d) | 1999-07-15 → 1999-06-14 (-31d) |  | 0% → 80% | 0d → 0.1d |
| 21 | **Plan for Next Iteration** | 1999-07-16 → 1999-06-14 (-32d) | 1999-07-20 → 1999-06-17 (-33d) |  |  |  |
| 22 | Develop Iteration Plan | 1999-07-16 → 1999-06-14 (-32d) | 1999-07-16 → 1999-06-15 (-31d) |  |  |  |
| 23 | Develop Business Case | 1999-07-19 → 1999-06-15 (-34d) | 1999-07-19 → 1999-06-16 (-33d) |  |  |  |
| 24 | Iteration Plan Review | 1999-07-20 → 1999-06-16 (-34d) | 1999-07-20 → 1999-06-17 (-33d) |  |  |  |
| 25 | **Manage Iteration** |  | 1999-08-17 → 1999-07-15 (-33d) | 43.8d → 20d |  |  |
| 26 | Acquire Staff |  | 1999-07-27 → 1999-06-24 (-33d) |  |  | 0.5d → 0d |
| 27 | Initiate Iteration | 1999-07-27 → 1999-06-24 (-33d) | 1999-08-03 → 1999-07-01 (-33d) |  |  | 0.5d → 0d |
| 28 | Assess Iteration | 1999-08-04 → 1999-07-01 (-34d) | 1999-08-10 → 1999-07-08 (-33d) |  |  |  |
| 29 | Iteration Evaluation Criteria Review | 1999-08-04 → 1999-07-01 (-34d) | 1999-08-10 → 1999-07-08 (-33d) |  |  |  |
| 30 | Iteration Acceptance Review | 1999-08-11 → 1999-07-08 (-34d) | 1999-08-17 → 1999-07-15 (-33d) |  |  |  |
| 31 | **Monitor and Control Project** | 1999-08-11 → 1999-07-08 (-34d) | 1999-09-07 → 1999-08-05 (-33d) |  |  |  |
| 32 | Schedule and Assign Work | 1999-08-11 → 1999-07-08 (-34d) | 1999-08-17 → 1999-07-15 (-33d) |  |  |  |
| 33 | Monitor Project Status | 1999-08-18 → 1999-07-15 (-34d) | 1999-08-24 → 1999-07-22 (-33d) |  |  |  |
| 34 | Report Status | 1999-08-25 → 1999-07-22 (-34d) | 1999-08-31 → 1999-07-29 (-33d) |  |  |  |
| 35 | Handle Exceptions and Problems | 1999-09-01 → 1999-07-29 (-34d) | 1999-09-07 → 1999-08-05 (-33d) |  |  |  |
| 36 | Project Review Authority (PRA) Project Review | 1999-09-01 → 1999-07-29 (-34d) | 1999-09-07 → 1999-08-05 (-33d) |  |  |  |
| 37 | **Reevaluate Project Scope and Risk** | 1999-08-18 → 1999-07-15 (-34d) | 1999-08-19 → 1999-07-19 (-31d) |  |  |  |
| 38 | Identify and Assess Risks | 1999-08-18 → 1999-07-15 (-34d) | 1999-08-18 → 1999-07-16 (-33d) |  |  |  |
| 39 | Develop Business Case | 1999-08-19 → 1999-07-16 (-34d) | 1999-08-19 → 1999-07-19 (-31d) |  |  |  |
| 40 | **Requirements** |  | 1999-08-05 → 1999-07-02 (-34d) | 68.2d → 44.4d | 52% → 68% |  |
| 42 | Capture a Common Vocabulary |  | 1999-05-07 A → 1999-05-06 A (-1d) |  |  |  |
| 52 | **Define the System** |  |  |  | 20% → 80% | 50.8d → 27d |
| 53 | Capture a Common Vocabulary |  |  |  | 50% → 80% | 51.1d → 31.8d |
| 54 | Find Actors and Use Cases |  |  |  | 10% → 80% | 50.8d → 29.4d |
| 55 | Manage Dependencies | 1999-06-09 A |  |  | 0% → 80% | 50.8d → 27d |
| 56 | **Manage the Scope of the System** | 1999-06-02 A → 1999-06-01 A (-1d) |  | 8d → 9d | 30% → 50% | 62d → 38.2d |
| 57 | Develop Vision |  |  |  | 10% → 50% | 65d → 41.2d |
| 58 | Manage Dependencies | 1999-06-09 A |  |  | 0% → 30% | 62d → 38.2d |
| 59 | Prioritize Use Cases | 1999-06-02 A → 1999-06-01 A (-1d) | 1999-06-04 → 1999-06-03 (-1d) |  | 80% → 70% | 55.8d → 31.8d |
| 60 | **Refine the System Definition** | 1999-07-21 → 1999-06-17 (-34d) | 1999-08-05 → 1999-07-02 (-34d) |  |  |  |
| 61 | Detail a Use Case | 1999-07-21 → 1999-06-17 (-34d) | 1999-07-28 → 1999-06-24 (-34d) |  |  |  |
| 62 | Detail the Software Requirements | 1999-07-28 → 1999-06-25 (-33d) | 1999-08-05 → 1999-07-02 (-34d) |  |  |  |
| 63 | Model the User Interface | 1999-07-21 → 1999-06-17 (-34d) | 1999-07-28 → 1999-06-24 (-34d) |  |  |  |
| 64 | Prototype the User Interface | 1999-07-28 → 1999-06-25 (-33d) | 1999-08-05 → 1999-07-02 (-34d) |  |  |  |
| 65 | **Manage Changing Requirements** |  |  |  | 33% → 67% | 59d → 35.2d |
| 66 | Structure the Use-Case Model |  | 1999-06-04 A |  | 90% → 100% | 57.1d → none |
| 67 | Manage Dependencies | 1999-06-07 A |  |  | 0% → 50% | 57.1d → 33.3d |
| 68 | Review Requirements |  |  |  | 10% → 50% | 59d → 35.2d |
| 69 | **Analysis and Design** | 1999-07-21 → 1999-06-17 (-34d) | 1999-08-10 → 1999-07-08 (-33d) |  |  |  |
| 70 | **Perform Architectural Synthesis** | 1999-07-21 → 1999-06-17 (-34d) | 1999-08-10 → 1999-07-08 (-33d) |  |  |  |
| 71 | Architectural Analysis | 1999-07-21 → 1999-06-17 (-34d) | 1999-07-27 → 1999-06-24 (-33d) |  |  |  |
| 72 | Construct Architectural Proof-of-Concept | 1999-07-28 → 1999-06-24 (-34d) | 1999-08-03 → 1999-07-01 (-33d) |  |  |  |
| 73 | Assess Viability of Architectural Proof-of-Concept | 1999-08-04 → 1999-07-01 (-34d) | 1999-08-10 → 1999-07-08 (-33d) |  |  |  |
| 74 | **Test** | 1999-06-01 → 1999-05-31 A (-1d) | 1999-06-01 → 1999-05-31 A (-1d) |  | 0% → 100% | 70d → none |
| 75 | **Plan Test** | 1999-06-01 → 1999-05-31 A (-1d) | 1999-06-01 → 1999-05-31 A (-1d) |  | 0% → 100% | 70d → none |
| 76 | Plan Test | 1999-06-01 → 1999-05-31 A (-1d) | 1999-06-01 → 1999-05-31 A (-1d) |  | 0% → 100% | 70d → none |
| 77 | **Environment** |  | 1999-07-30 → 1999-06-24 (-36d) | 61.6d → 35.6d | 17% → 32% | 27.4d → 29.6d |
| 83 | **Prepare Environment for an Iteration** | 1999-07-16 → 1999-06-14 (-32d) | 1999-07-20 → 1999-06-17 (-33d) |  |  | 27.4d → 29.68d |
| 84 | Develop Development Case | 1999-07-16 → 1999-06-14 (-32d) | 1999-07-16 → 1999-06-15 (-31d) |  |  | 27.4d → 29.68d |
| 85 | Develop Project-Specific Templates | 1999-07-19 → 1999-06-15 (-34d) | 1999-07-19 → 1999-06-16 (-33d) |  |  | 27.4d → 29.68d |
| 86 | Launch Development Case | 1999-07-20 → 1999-06-16 (-34d) | 1999-07-20 → 1999-06-17 (-33d) |  |  | 27.4d → 29.68d |
| 87 | Set Up Tools | 1999-07-16 → 1999-06-14 (-32d) | 1999-07-16 → 1999-06-15 (-31d) |  |  | 28.4d → 30.68d |
| 88 | Verify Tool Configuration & Installation | 1999-07-19 → 1999-06-15 (-34d) | 1999-07-19 → 1999-06-16 (-33d) |  |  | 28.4d → 30.68d |
| 89 | **Prepare Guidelines for an Iteration** | 1999-07-16 → 1999-06-10 A (-36d) | 1999-07-26 → 1999-06-22 (-34d) | 6.1d → 8.3d | 0% → 19% |  |
| 90 | Develop Business-Modeling Guidelines | 1999-07-16 → 1999-06-10 A (-36d) | 1999-07-21 → 1999-06-15 (-36d) |  | 0% → 30% | 34.9d → 37.1d |
| 91 | Develop Use-Case Modeling Guidelines | 1999-07-16 → 1999-06-17 (-29d) | 1999-07-19 → 1999-06-18 (-31d) |  |  | 36.1d → 33.3d |
| 92 | Develop User-Interface Guidelines | 1999-07-16 → 1999-06-10 A (-36d) | 1999-07-21 → 1999-06-15 (-36d) |  | 0% → 30% | 34.9d → 37.1d |
| 93 | Develop Design Guidelines | 1999-07-16 → 1999-06-10 A (-36d) | 1999-07-21 → 1999-06-15 (-36d) |  | 0% → 30% | 33.9d → 36.1d |

| ID | Task | Start | Finish | Duration | Complete | Total float |
| --- | --- | --- | --- | --- | --- | --- |
| 94 | Develop Programming Guidelines | 1999-07-21 → 1999-06-15 (-36d) | 1999-07-22 → 1999-06-16 (-36d) |  |  | 33.9d → 36.1d |
| 95 | Develop Manual Styleguide | 1999-07-16 → 1999-06-10 A (-36d) | 1999-07-21 → 1999-06-15 (-36d) |  | 0% → 30% | 34.9d → 37.1d |
| 96 | Develop Test Guidelines | 1999-07-16 → 1999-06-10 A (-36d) | 1999-07-21 → 1999-06-15 (-36d) |  | 0% → 30% | 34.9d → 37.1d |
| 97 | Develop Tool Guidelines | 1999-07-21 → 1999-06-17 (-34d) | 1999-07-26 → 1999-06-22 (-34d) |  |  |  |
| 98 | **Support Environment During an Iteration** | 1999-07-21 → 1999-06-15 A (-36d) | 1999-07-30 → 1999-06-24 (-36d) |  | 0% → 30% | 27.4d → 29.6d |
| 99 | Support Development | 1999-07-21 → 1999-06-15 A (-36d) | 1999-07-30 → 1999-06-24 (-36d) |  | 0% → 30% | 27.4d → 29.6d |
| 100 | **Configuration & Change Management** |  | 1999-08-25 → 1999-07-16 (-40d) | 79.7d → 51.6d | 3% → 5% | 9.3d → 13.6d |
| 105 | **Create Project CM Environments** | 1999-07-16 → 1999-06-10 A (-36d) | 1999-07-21 → 1999-06-15 (-36d) | 3.1d → 3.2d | 0% → 15% | 9.3d → 12.68d |
| 106 | Setup CM Environment | 1999-07-16 → 1999-06-14 A (-32d) | 1999-07-16 → 1999-06-15 (-31d) |  | 0% → 10% | 11.4d → 12.68d |
| 107 | Create Integration Workspaces | 1999-07-16 → 1999-06-10 A (-36d) | 1999-07-21 → 1999-06-15 (-36d) |  | 0% → 20% | 9.3d → 12.78d |
| 108 | **Change and Deliver Configuration Items** | 1999-07-21 → 1999-06-11 A (-40d) | 1999-08-25 → 1999-07-16 (-40d) |  | 0% → 5% | 9.3d → 13.6d |
| 109 | Create Development Workspace | 1999-07-21 → 1999-06-11 A (-40d) | 1999-07-30 → 1999-06-22 (-38d) |  | 0% → 20% | 9.3d → 13.6d |
| 110 | Make Changes | 1999-07-30 → 1999-06-22 (-38d) | 1999-08-09 → 1999-06-30 (-40d) |  |  | 9.3d → 13.6d |
| 111 | Deliver Changes | 1999-08-09 → 1999-06-30 (-40d) | 1999-08-17 → 1999-07-08 (-40d) |  |  | 9.3d → 13.6d |
| 112 | Update Workspace | 1999-08-17 → 1999-07-08 (-40d) | 1999-08-25 → 1999-07-16 (-40d) |  |  | 9.3d → 13.6d |
| 113 | Create Baselines | 1999-07-21 → 1999-06-11 A (-40d) | 1999-07-29 → 1999-06-22 (-37d) |  | 0% → 10% | 10.9d → 13.6d |
| 114 | Promote Baselines | 1999-07-29 → 1999-06-22 (-37d) | 1999-08-06 → 1999-06-30 (-37d) |  |  | 10.9d → 13.6d |
| 115 | **Manage Baselines and Releases** | 1999-07-21 → 1999-06-17 (-34d) | 1999-08-24 → 1999-07-16 (-39d) | 24d → 21.4d |  | 10.9d → 13.6d |
| 116 | Create Deployment Unit | 1999-07-21 → 1999-06-17 (-34d) | 1999-07-29 → 1999-06-25 (-34d) |  |  | 16.9d → 17d |
| 117 | Create Baselines | 1999-08-06 → 1999-06-30 (-37d) | 1999-08-16 → 1999-07-08 (-39d) |  |  | 10.9d → 13.6d |
| 118 | Promote Baselines | 1999-08-16 → 1999-07-08 (-39d) | 1999-08-24 → 1999-07-16 (-39d) |  |  | 10.9d → 13.6d |
| 119 | **Manage Change Requests** | 1999-07-21 → 1999-06-17 (-34d) | 1999-08-24 → 1999-07-16 (-39d) | 24d → 21.4d |  | 10.9d → 13.6d |
| 120 | Submit Change Request | 1999-07-21 → 1999-06-17 (-34d) | 1999-07-29 → 1999-06-25 (-34d) |  |  | 22.9d → 23d |
| 121 | Update Change Request | 1999-07-29 → 1999-06-25 (-34d) | 1999-08-06 → 1999-07-05 (-32d) |  |  | 22.9d → 23d |
| 122 | Review Change Request | 1999-07-21 → 1999-06-17 (-34d) | 1999-07-29 → 1999-06-25 (-34d) |  |  | 22.9d → 23d |
| 123 | Confirm Duplicate or Rejected Change Request | 1999-07-29 → 1999-06-25 (-34d) | 1999-08-06 → 1999-07-05 (-32d) |  |  | 22.9d → 23d |
| 124 | Verify Changes in Build | 1999-08-16 → 1999-07-08 (-39d) | 1999-08-24 → 1999-07-16 (-39d) |  |  | 10.9d → 13.6d |
| 125 | **Monitor and Report Configuration Status** | 1999-07-29 → 1999-06-25 (-34d) | 1999-08-16 → 1999-07-13 (-34d) |  |  | 16.9d → 17d |
| 126 | Report on Configuration Status | 1999-07-29 → 1999-06-25 (-34d) | 1999-08-06 → 1999-07-05 (-32d) |  |  | 16.9d → 17d |
| 127 | Perform Configuration Audits | 1999-08-06 → 1999-07-05 (-32d) | 1999-08-16 → 1999-07-13 (-34d) |  |  | 16.9d → 17d |

## Version 7 (saved 1999-06-19, file detail_inception_iter_19990618.mpp)

Last finish stays 1999-08-05. Complete tasks 30 → 40.

Changed:

| ID | Task | Start | Finish | Complete | Total float |
| --- | --- | --- | --- | --- | --- |
| 1 | **Inception Phase** |  |  | 32% → 39% |  |
| 2 | **Project Management** |  |  | 28% → 32% |  |
| 11 | **Develop Software Development Plan** |  |  | 95% → 97% | 0.1d → 2.6d |
| 19 | Compile Software Development Plan |  |  | 80% → 90% | 0.1d → 2.6d |
| 20 | Project Planning Review |  |  | 80% → 90% | 0.1d → 2.6d |
| 21 | **Plan for Next Iteration** | 1999-06-14 A |  | 0% → 87% |  |
| 22 | Develop Iteration Plan | 1999-06-14 A |  | 0% → 80% | 0d → 2d |
| 23 | Develop Business Case | 1999-06-15 A | 1999-06-16 A | 0% → 100% | 0d → none |
| 24 | Iteration Plan Review | 1999-06-16 A |  | 0% → 80% |  |
| 40 | **Requirements** |  |  | 68% → 74% |  |
| 52 | **Define the System** |  | 1999-06-11 A | 80% → 100% | 27d → none |
| 53 | Capture a Common Vocabulary |  | 1999-06-03 A | 80% → 100% | 31.8d → none |
| 54 | Find Actors and Use Cases |  | 1999-06-08 A | 80% → 100% | 29.4d → none |
| 55 | Manage Dependencies |  | 1999-06-11 A | 80% → 100% | 27d → none |
| 56 | **Manage the Scope of the System** |  |  | 50% → 93% | 38.2d → 27d |
| 57 | Develop Vision |  | 1999-06-08 A | 50% → 100% | 41.2d → none |
| 58 | Manage Dependencies |  | 1999-06-11 A | 30% → 100% | 38.2d → none |
| 59 | Prioritize Use Cases |  |  | 70% → 80% | 31.8d → 33d |
| 77 | **Environment** |  |  | 32% → 61% |  |
| 83 | **Prepare Environment for an Iteration** | 1999-06-14 A |  | 0% → 82% |  |
| 84 | Develop Development Case | 1999-06-14 A | 1999-06-15 A | 0% → 100% | 29.68d → none |
| 85 | Develop Project-Specific Templates | 1999-06-15 A | 1999-06-16 A | 0% → 100% | 29.68d → none |
| 86 | Launch Development Case | 1999-06-16 A |  | 0% → 50% |  |
| 87 | Set Up Tools | 1999-06-14 A |  | 0% → 80% | 30.68d → 31.48d |
| 88 | Verify Tool Configuration & Installation | 1999-06-15 A |  | 0% → 80% |  |
| 89 | **Prepare Guidelines for an Iteration** |  |  | 19% → 53% |  |
| 90 | Develop Business-Modeling Guidelines |  | 1999-06-15 A | 30% → 100% | 37.1d → none |
| 91 | Develop Use-Case Modeling Guidelines | 1999-06-17 A |  | 0% → 50% |  |
| 92 | Develop User-Interface Guidelines |  |  | 30% → 50% |  |
| 93 | Develop Design Guidelines |  |  | 30% → 50% | 36.1d → 36.6d |
| 94 | Develop Programming Guidelines | 1999-06-15 A |  | 0% → 50% |  |
| 95 | Develop Manual Styleguide |  |  | 30% → 50% |  |
| 96 | Develop Test Guidelines |  |  | 30% → 50% |  |
| 97 | Develop Tool Guidelines | 1999-06-17 A |  | 0% → 20% |  |
| 100 | **Configuration & Change Management** |  |  | 5% → 12% |  |
| 105 | **Create Project CM Environments** |  |  | 15% → 75% | 12.68d → 2d |
| 106 | Setup CM Environment |  | 1999-06-15 A | 10% → 100% | 12.68d → none |
| 107 | Create Integration Workspaces |  |  | 20% → 50% | 12.78d → 2.1d |
| 108 | **Change and Deliver Configuration Items** |  |  | 5% → 12% |  |
| 109 | Create Development Workspace |  |  | 20% → 40% |  |
| 113 | Create Baselines |  |  | 10% → 30% |  |
| 115 | **Manage Baselines and Releases** | 1999-06-17 A |  | 0% → 7% |  |
| 116 | Create Deployment Unit | 1999-06-17 A |  | 0% → 20% |  |
| 119 | **Manage Change Requests** | 1999-06-17 A |  | 0% → 8% |  |
| 120 | Submit Change Request | 1999-06-17 A |  | 0% → 20% |  |
| 122 | Review Change Request | 1999-06-17 A |  | 0% → 20% |  |

## Version 8 (saved 1999-06-25, file detail_inception_iter_19990625.mpp)

Last finish stays 1999-08-05. Complete tasks 40 → 55.

Changed:

| ID | Task | Start | Finish | Complete | Total float |
| --- | --- | --- | --- | --- | --- |
| 1 | **Inception Phase** |  |  | 39% → 55% |  |
| 2 | **Project Management** |  |  | 32% → 38% |  |
| 25 | **Manage Iteration** |  |  | 2% → 20% |  |
| 26 | Acquire Staff |  |  | 10% → 80% | 0d → 1d |
| 27 | Initiate Iteration | 1999-06-24 A |  | 0% → 20% |  |
| 40 | **Requirements** |  |  | 74% → 93% |  |
| 60 | **Refine the System Definition** | 1999-06-17 A |  | 0% → 63% |  |
| 61 | Detail a Use Case | 1999-06-17 A | 1999-06-24 A | 0% → 100% | 23.8d → none |
| 62 | Detail the Software Requirements | 1999-06-25 A |  | 0% → 25% |  |
| 63 | Model the User Interface | 1999-06-17 A | 1999-06-24 A | 0% → 100% | 23.8d → none |
| 64 | Prototype the User Interface | 1999-06-25 A |  | 0% → 25% |  |
| 65 | **Manage Changing Requirements** |  | 1999-06-16 A | 67% → 100% | 35.2d → none |
| 67 | Manage Dependencies |  | 1999-06-16 A | 50% → 100% | 34.7d → none |
| 68 | Review Requirements |  | 1999-06-16 A | 50% → 100% | 35.2d → none |
| 69 | **Analysis and Design** | 1999-06-17 A |  | 0% → 40% |  |
| 70 | **Perform Architectural Synthesis** | 1999-06-17 A |  | 0% → 40% |  |
| 71 | Architectural Analysis | 1999-06-17 A | 1999-06-24 A | 0% → 100% | 0d → none |
| 72 | Construct Architectural Proof-of-Concept | 1999-06-24 A |  | 0% → 20% |  |
| 77 | **Environment** |  |  | 61% → 78% |  |
| 83 | **Prepare Environment for an Iteration** |  | 1999-06-17 A | 82% → 100% | 29.68d → none |
| 86 | Launch Development Case |  | 1999-06-17 A | 50% → 100% | 29.68d → none |
| 87 | Set Up Tools |  | 1999-06-15 A | 80% → 100% | 31.48d → none |
| 88 | Verify Tool Configuration & Installation |  | 1999-06-16 A | 80% → 100% | 30.68d → none |
| 89 | **Prepare Guidelines for an Iteration** |  |  | 53% → 90% |  |
| 91 | Develop Use-Case Modeling Guidelines |  | 1999-06-18 A | 50% → 100% | 33.3d → none |
| 92 | Develop User-Interface Guidelines |  | 1999-06-15 A | 50% → 100% | 37.1d → none |
| 93 | Develop Design Guidelines |  | 1999-06-15 A | 50% → 100% | 36.6d → none |
| 94 | Develop Programming Guidelines |  | 1999-06-16 A | 50% → 100% | 36.1d → none |
| 95 | Develop Manual Styleguide |  | 1999-06-15 A | 50% → 100% | 37.1d → none |
| 96 | Develop Test Guidelines |  | 1999-06-15 A | 50% → 100% | 37.1d → none |
| 100 | **Configuration & Change Management** |  |  | 12% → 28% |  |
| 105 | **Create Project CM Environments** |  | 1999-06-15 A | 75% → 100% | 2d → none |
| 107 | Create Integration Workspaces |  | 1999-06-15 A | 50% → 100% | 2.1d → none |
| 108 | **Change and Deliver Configuration Items** |  |  | 12% → 33% |  |
| 109 | Create Development Workspace |  |  | 40% → 80% | 13.6d → 14.8d |
| 110 | Make Changes | 1999-06-22 A |  | 0% → 20% |  |
| 113 | Create Baselines |  |  | 30% → 80% | 13.6d → 14.8d |
| 114 | Promote Baselines | 1999-06-22 A |  | 0% → 20% |  |
| 119 | **Manage Change Requests** |  |  | 8% → 30% |  |
| 120 | Submit Change Request |  |  | 20% → 80% | 23d → 24.2d |
| 121 | Update Change Request | 1999-06-25 A |  | 0% → 20% |  |
| 122 | Review Change Request |  |  | 20% → 50% |  |
| 125 | **Monitor and Report Configuration Status** | 1999-06-25 A |  | 0% → 10% |  |
| 126 | Report on Configuration Status | 1999-06-25 A |  | 0% → 20% |  |
